# Book Publication

Schedule from MS Project, 2011-08-20 to 2012-01-02.
Office Training Services, Inc.

## Calendars

- Standard: Mon-Fri 08:00-12:00, 13:00-17:00; Sat-Sun off.

## Schedule

| ID | WBS | Task | Type | Duration | Start | Finish | Predecessors | Total slack | Free slack |
| --- | --- | --- | --- | --- | --- | --- | --- | --- | --- |
| 1 | 1 | **Write Book** |  | 72d | 2011-08-22 | 2011-11-29 |  | 0d |  |
| 2 | 1.1 | Complete Outline |  | 3d | 2011-08-22 | 2011-08-24 |  | 93d |  |
| 3 | 1.2 | Write First Draft |  | 45d | 2011-08-22 | 2011-10-21 |  | 0d |  |
| 4 | 1.3 | Edit First Draft |  | 8d | 2011-10-24 | 2011-11-02 | 3 | 24d | 0d |
| 5 | 1.4 | Complete Author Revisions |  | 12d | 2011-11-03 | 2011-11-18 | 4 | 24d | 0d |
| 6 | 1.5 | Edit Final Draft |  | 7d | 2011-11-21 | 2011-11-29 | 5 | 24d | 0d |
| 7 | 1.6 | Manuscript Complete | milestone | 0d | 2011-11-29 | 2011-11-29 | 6 | 24d |  |
| 8 | 2 | **Illustrate Book** |  | 34d | 2011-10-24 | 2011-12-08 |  | 0d |  |
| 9 | 2.1 | Complete Initial Sketches |  | 26d | 2011-10-24 | 2011-11-28 | 3 | 0d |  |
| 10 | 2.2 | Approve Sketches |  | 2d | 2011-11-29 | 2011-11-30 | 9 | 0d |  |
| 11 | 2.3 | Complete Illustrations |  | 6d | 2011-12-01 | 2011-12-08 | 10 | 0d |  |
| 12 | 2.4 | Send Book to Production | milestone | 0d | 2011-12-08 | 2011-12-08 | 11 | 0d |  |
| 13 | 3 | **Book Production** |  | 17d | 2011-12-09 | 2012-01-02 | 12 | 0d |  |
| 14 | 3.1 | Print Book |  | 5d | 2011-12-09 | 2011-12-15 |  | 0d |  |
| 15 | 3.2 | Print Cover |  | 3d | 2011-12-09 | 2011-12-13 |  | 14d |  |
| 16 | 3.3 | Review and Approve Proofs |  | 3d | 2011-12-16 | 2011-12-20 | 14 | 0d |  |
| 17 | 3.4 | Print Final Book with Cover |  | 9d | 2011-12-21 | 2012-01-02 | 16 | 0d |  |
| 18 | 4 | **Book Distribution** |  | 7d | 2011-08-22 | 2011-08-30 |  | 71d |  |
| 19 | 4.1 | Package Books |  | 4d | 2011-08-22 | 2011-08-25 |  | 71d | 0d |
| 20 | 4.2 | Ship Books to Bookstores |  | 3d | 2011-08-26 | 2011-08-30 | 19 | 71d | 0d |
| 21 | 4.3 | Release Books | milestone | 0d | 2011-08-30 | 2011-08-30 | 20 | 71d | 0d |
| 22 | 5 | **Publicity and Marketing** |  | 25d | 2011-08-20 | 2011-09-23 |  | 71d |  |
| 23 | 5.1 | Develop PR Strategy |  | 4d | 2011-08-22 | 2011-08-25 |  | 88d | 0d |
| 24 | 5.2 | Write Promotional Material |  | 12d | 2011-08-22 | 2011-09-06 |  | 83d | 0d |

| ID | WBS | Task | Type | Duration | Start | Finish | Predecessors | Total slack | Free slack | Constraint |
| --- | --- | --- | --- | --- | --- | --- | --- | --- | --- | --- |
| 25 | 5.3 | **Create Author's Tour** |  | 5d | 2011-08-22 | 2011-08-26 |  | 73d | 2d |  |
| 26 | 5.3.1 | Schedule Signings |  | 4d | 2011-08-22 | 2011-08-25 |  | 73d | 0d |  |
| 27 | 5.3.2 | Make Travel Arrangements |  | 1d | 2011-08-26 | 2011-08-26 | 26 | 73d |  |  |
| 28 | 5.4 | **Plan Launch Party** |  | 4d | 2011-08-26 | 2011-08-31 | 23 | 88d |  |  |
| 29 | 5.4.1 | Make Guest List |  | 2d | 2011-08-26 | 2011-08-29 |  | 90d |  | start no earlier than 1996-09-16 |
| 30 | 5.4.2 | Hire Caterer |  | 1d | 2011-08-26 | 2011-08-26 |  | 91d |  |  |
| 31 | 5.4.3 | Send Invitations |  | 4d | 2011-08-26 | 2011-08-31 |  | 88d |  | start no earlier than 1996-11-04 |
| 32 | 5.5 | **Launch Publicity Campaign** |  | 25d | 2011-08-20 | 2011-09-23 |  | 71d |  |  |
| 33 | 5.5.1 | Submit Ads |  | 1d | 2011-09-07 | 2011-09-07 | 24 | 83d |  |  |
| 34 | 5.5.2 | Hold Author's Tour |  | 18d | 2011-08-31 | 2011-09-23 | 21, 25 | 71d |  |  |
| 35 | 5.5.3 | Launch Book | milestone | 0d | 2011-08-20 | 2011-08-20 |  | 96d |  |  |
