# Build Structure

Schedule from MS Project, 2011-08-09 to 2011-10-04, costs in $.
Office Training Services, Inc.

## Calendars

- Standard: Mon-Fri 08:00-12:00, 13:00-17:00; Sat-Sun off.

## Resources

| Resource |
| --- |
| Backhoe Operator |
| Backhoe |
| Laborer |
| Carpenter |
| Roofer |

## Schedule

| ID | WBS | Task | Duration | Start | Finish | Predecessors | Total slack | Constraint | Resources | Work | Cost |
| --- | --- | --- | --- | --- | --- | --- | --- | --- | --- | --- | --- |
| 1 | 1 | **Build Structure** | 40.5d | 2011-08-09 | 2011-10-04 |  | 0d |  |  | 720h | 29,500 |
| 2 | 1.1 | **Build Foundation** | 6.5d | 2011-08-09 | 2011-08-17 |  | 0d |  |  | 200h |  |
| 3 | 1.1.1 | Dig Foundation | 3d | 2011-08-09 | 2011-08-11 |  | 0d | start no earlier than 2011-08-09 | Backhoe Operator [200%]; Backhoe [200%] | 96h |  |
| 4 | 1.1.2 | Smooth Foundation | 2.5d | 2011-08-12 | 2011-08-16 | 3FS-1d | 0d |  | Backhoe Operator [200%]; Backhoe [200%] | 96h |  |
| 5 | 1.1.3 | Pour Foundation | 1d | 2011-08-16 | 2011-08-17 | 4 | 0d |  | Laborer | 8h |  |
| 6 | 1.2 | **Construct Frame** | 10d | 2011-08-19 | 2011-09-02 | 2FS+2d | 0d |  |  | 192h | 26,500 |
| 7 | 1.2.1 | Frame House | 6d | 2011-08-19 | 2011-08-29 |  | 0d |  | Carpenter [300%] | 144h | 20,000 |
| 8 | 1.2.2 | Frame Garage | 3d | 2011-08-30 | 2011-09-02 | 7 | 0d |  | Carpenter [200%] | 48h | 6,500 |
| 9 | 1.3 | Install Roof | 1w | 2011-09-02 | 2011-09-09 | 6 | 0d |  | Roofer [200%] | 80h |  |
| 10 | 1.4 | Install Doors | 3d | 2011-09-09 | 2011-09-14 | 9 | 0d |  | Laborer [200%] | 48h |  |
| 11 | 1.5 | Install Windows | 4d | 2011-09-16 | 2011-09-22 | 10 | 0d |  | Laborer [200%] | 72h |  |
| 12 | 1.6 | Install Siding | 1w | 2011-09-22 | 2011-09-29 | 11 | 0d |  | Laborer [200%] | 80h |  |
| 13 | 1.7 | Build Deck | 3d | 2011-09-29 | 2011-10-04 | 12 | 0d |  | Carpenter [200%] | 48h | 3,000 |
