# Building Project

Schedule from MS Project, 2005-08-22 to 2005-12-06, costs in $.
Office Training Services, Inc.

## Calendars

- Standard: Mon-Fri 08:00-12:00, 13:00-17:00; Sat-Sun off.

## Resources

| Resource |
| --- |
| Surveyor |
| Architect |
| Contracting Specialist |
| Superintendent |
| Backhoe Operator |
| Backhoe |
| Laborer |
| Carpenter |
| Roofer |
| Plumber |
| Electrician |
| Cable Specialist |
| Phone Technician |
| Painter |
| Carpet Layer |

## Schedule

| ID | WBS | Task | Type | Duration | Start | Finish | Predecessors | Total slack | Free slack | Constraint | Resources | Work | Cost |
| --- | --- | --- | --- | --- | --- | --- | --- | --- | --- | --- | --- | --- | --- |
| 1 | 1 | Conduct Site Survey |  | 1d | 2005-08-22 | 2005-08-22 |  | 41d | 0d |  | Surveyor [200%] | 16h |  |
| 2 | 2 | Develop Blueprints |  | 2w | 2005-08-23 | 2005-09-05 | 1 | 41d | 0d |  | Architect | 72h |  |
| 3 | 3 | Draft Proposal |  | 3d | 2005-09-06 | 2005-09-08 | 2 | 41d | 0d |  | Contracting Specialist | 24h |  |
| 4 | 4 | Request Bids |  | 1w | 2005-09-09 | 2005-09-15 | 3 | 41d | 0d |  | Contracting Specialist | 40h |  |
| 5 | 5 | Request Permits |  | 1d | 2005-09-16 | 2005-09-16 | 4 | 41d | 0d |  | Contracting Specialist | 8h |  |
| 6 | 6 | Obtain Permits |  | 1w | 2005-09-19 | 2005-09-23 | 5 | 41d | 0d |  | Contracting Specialist | 40h | 500 |
| 7 | 7 | Obtain Bids |  | 1w | 2005-09-27 | 2005-10-03 | 6FS+1d | 41d | 0d |  | Contracting Specialist [50%]; Superintendent [50%] | 40h |  |
| 8 | 8 | Select Subcontractors |  | 1w | 2005-10-04 | 2005-10-10 | 7 | 41d | 0d | start no earlier than 2002-07-29 | Superintendent | 40h |  |
| 9 | 9 | Complete Planning Phase | milestone | 0d | 2005-10-10 | 2005-10-10 | 8 | 41d |  |  |  |  |  |
| 10 | 10 | **Build Structure** |  | 43d | 2005-08-22 | 2005-10-19 |  | 0d |  |  |  | 712h | 29,500 |
| 11 | 10.1 | **Build Foundation** |  | 10d | 2005-08-22 | 2005-09-02 |  | 0d |  |  |  | 192h |  |
| 12 | 10.1.1 | Dig Foundation |  | 3d | 2005-08-22 | 2005-08-24 |  | 0d |  |  | Backhoe Operator [200%]; Backhoe [200%] | 96h |  |
| 13 | 10.1.2 | Smooth Foundation |  | 1d | 2005-08-25 | 2005-08-25 | 12FS-1d | 0d |  |  | Backhoe Operator [200%]; Backhoe [200%] | 48h |  |
| 14 | 10.1.3 | Pour Foundation |  | 6d | 2005-08-26 | 2005-09-02 | 13 | 0d |  |  | Laborer | 48h |  |
| 15 | 10.2 | **Construct Frame** |  | 10d | 2005-09-07 | 2005-09-20 | 11FS+2d | 0d |  |  |  | 192h | 26,500 |
| 16 | 10.2.1 | Frame House |  | 6d | 2005-09-07 | 2005-09-14 |  | 0d |  |  | Carpenter [300%] | 144h | 20,000 |
| 17 | 10.2.2 | Frame Garage |  | 3d | 2005-09-16 | 2005-09-20 | 16 | 0d |  |  | Carpenter [200%] | 48h | 6,500 |
| 18 | 10.3 | Install Roof |  | 1w | 2005-09-21 | 2005-09-27 | 15 | 0d |  |  | Roofer [200%] | 80h |  |
| 19 | 10.4 | Install Doors |  | 2d | 2005-09-28 | 2005-09-29 | 18 | 0d |  |  | Laborer [200%] | 32h |  |
| 20 | 10.5 | Install Windows |  | 5d | 2005-10-03 | 2005-10-07 | 19 | 0d |  |  | Laborer [200%] | 88h |  |
| 21 | 10.6 | Install Siding |  | 1w | 2005-10-10 | 2005-10-14 | 20 | 0d |  |  | Laborer [200%] | 80h |  |
| 22 | 10.7 | Build Deck |  | 3d | 2005-10-17 | 2005-10-19 | 21 | 0d |  |  | Carpenter [200%] | 48h | 3,000 |
| 23 | 11 | **Build Infrastructure** |  | 34d | 2005-10-20 | 2005-12-06 | 10 | 0d |  |  |  | 688h | 10,250 |
| 24 | 11.1 | Initial Plumbing |  | 7d | 2005-10-20 | 2005-10-28 |  | 0d |  |  | Plumber [200%] | 112h | 150 |
| 25 | 11.2 | Initial Electricity |  | 2w | 2005-10-20 | 2005-11-02 | 24SS | 0d |  |  | Electrician [300%] | 240h | 200 |
| 26 | 11.3 | Security System |  | 1d | 2005-11-03 | 2005-11-03 | 25 | 0d |  |  |  |  | 2,000 |
| 27 | 11.4 | Install Cable |  | 1d | 2005-11-03 | 2005-11-03 | 26SS | 0d |  |  | Cable Specialist | 8h |  |
| 28 | 11.5 | Run Phone Lines |  | 1d | 2005-11-03 | 2005-11-03 | 27SS | 0d |  |  | Phone Technician | 8h |  |
| 29 | 11.6 | Insulation |  | 2d | 2005-11-04 | 2005-11-07 | 28 | 0d |  |  | Laborer [300%] | 48h |  |
| 30 | 11.7 | Drywall |  | 4d | 2005-11-08 | 2005-11-11 | 29 | 0d |  |  | Laborer [200%] | 64h |  |
| 31 | 11.8 | Painting |  | 2d | 2005-11-14 | 2005-11-15 | 30 | 0d |  |  | Painter [400%] | 64h |  |
| 32 | 11.9 | Flooring |  | 1w | 2005-11-18 | 2005-11-24 | 31FS+2d | 0d |  |  | Laborer [200%] | 80h |  |
| 33 | 11.10 | Final Plumbing |  | 2d | 2005-11-25 | 2005-11-28 | 32 | 0d |  |  | Plumber | 16h |  |
| 34 | 11.11 | Final Electric |  | 1d | 2005-11-25 | 2005-11-25 | 33SS | 0d |  |  | Electrician [200%] | 16h |  |
| 35 | 11.12 | Cabinets |  | 2d | 2005-11-28 | 2005-11-29 | 34 | 0d |  |  |  |  | 5,400 |
| 36 | 11.13 | Wood Trim |  | 3d | 2005-11-30 | 2005-12-02 | 35 | 0d |  |  |  |  | 2,500 |
| 37 | 11.14 | Carpeting |  | 2d | 2005-12-05 | 2005-12-06 | 36 | 0d |  |  | Carpet Layer [200%] | 32h |  |
