# Complete Interior

Schedule from MS Project, 2011-10-11 to 2011-12-06, costs in $.
Office Training Services, Inc.

## Calendars

- Standard: Mon-Fri 08:00-12:00, 13:00-17:00; Sat-Sun off.

## Resources

| Resource |
| --- |
| Plumber |
| Electrician |
| Cable Specialist |
| Phone Technician |
| Laborer |
| Insulation |
| Drywall |
| Painter |
| Paint |
| Tile |
| Plumbing Supplies |
| Light Fixtures |
| Carpet Layer |
| Carpet |

## Schedule

| ID | WBS | Task | Duration | Start | Finish | Predecessors | Total slack | Free slack | Constraint | Resources | Work | Cost |
| --- | --- | --- | --- | --- | --- | --- | --- | --- | --- | --- | --- | --- |
| 1 | 1 | **Complete Interior** | 41d | 2011-10-11 | 2011-12-06 |  | 0d |  |  |  | 6550h | 10,250 |
| 2 | 1.1 | Initial Plumbing | 7d | 2011-10-11 | 2011-10-19 |  | 2d | 0d |  | Plumber [200%] | 112h | 150 |
| 3 | 1.2 | Initial Electricity | 2w | 2011-10-11 | 2011-10-24 | 2SS | 2d | 0d |  | Electrician [300%] | 240h | 200 |
| 4 | 1.3 | Security System | 1d | 2011-10-25 | 2011-10-25 | 3 | 2d | 0d | start no earlier than 2011-10-25 |  |  | 2,000 |
| 5 | 1.4 | Install Cable | 1d | 2011-10-25 | 2011-10-25 | 4SS | 2d | 0d |  | Cable Specialist | 8h |  |
| 6 | 1.5 | Run Phone Lines | 1d | 2011-10-25 | 2011-10-25 | 5SS | 2d | 0d |  | Phone Technician | 8h |  |
| 7 | 1.6 | Insulation | 4d | 2011-10-26 | 2011-10-31 | 6 | 2d | 0d |  | Laborer [300%]; Insulation [300000%] | 3096h |  |
| 8 | 1.7 | Drywall | 4d | 2011-11-01 | 2011-11-04 | 7 | 2d | 0d |  | Laborer [200%]; Drywall [17000%] | 234h |  |
| 9 | 1.8 | Painting | 3d | 2011-11-07 | 2011-11-09 | 8 | 2d | 0d |  | Painter [400%]; Paint [2000%] | 116h |  |
| 10 | 1.9 | Flooring | 1w | 2011-11-14 | 2011-11-18 | 9FS+2d | 2d | 0d |  | Laborer [200%]; Tile [35000%] | 430h |  |
| 11 | 1.10 | Final Plumbing | 3d | 2011-11-21 | 2011-11-23 | 10 | 2d | 0d |  | Plumber; Plumbing Supplies | 25h |  |
| 12 | 1.11 | Final Electric | 3d | 2011-11-21 | 2011-11-23 | 11SS | 2d |  |  | Electrician [200%]; Light Fixtures | 49h |  |
| 13 | 1.12 | Cabinets | 2d | 2011-11-28 | 2011-11-29 | 12 | 0d |  | start no earlier than 2011-11-26 |  |  | 5,400 |
| 14 | 1.13 | Wood Trim | 3d | 2011-11-30 | 2011-12-02 | 13 | 0d |  |  |  |  | 2,500 |
| 15 | 1.14 | Carpeting | 2d | 2011-12-05 | 2011-12-06 | 14 | 0d |  |  | Carpet Layer [200%]; Carpet [220000%] | 2232h |  |
