# Dwelling

Schedule from MS Project, 2011-05-12 to 2011-08-30, costs in $.
Office Training Services, Inc.

## Calendars

- Standard: Mon-Fri 08:00-12:00, 13:00-17:00; Sat-Sun off.

## Resources

| Resource |
| --- |
| Surveyor |
| Architect |
| Contracting Specialist |
| Superintendent |
| Backhoe Operator |
| Backhoe |
| Laborer |
| Concrete |
| Carpenter |
| Roofer |
| Roofing Materials |
| Doors |
| Windows |
| Siding Materials |

## Schedule

| ID | WBS | Task | Type | Duration | Start | Finish | Predecessors | Total slack | Constraint | Resources | Work | Cost |
| --- | --- | --- | --- | --- | --- | --- | --- | --- | --- | --- | --- | --- |
| 1 | 1 | **Plan** |  | 37.88d | 2011-05-12 | 2011-07-04 |  | 0d |  |  | 287.5h | 500 |
| 2 | 1.1 | Conduct Site Survey |  | 1d | 2011-05-12 | 2011-05-12 |  | 0d |  | Surveyor [200%] | 16h |  |
| 3 | 1.2 | Develop Blueprints |  | 2w | 2011-05-13 | 2011-05-26 | 2 | 0d |  | Architect | 72h |  |
| 4 | 1.3 | Draft Proposal |  | 3d | 2011-05-27 | 2011-05-31 | 3 | 0d |  | Contracting Specialist | 24h |  |
| 5 | 1.4 | Request Bids |  | 1w | 2011-06-01 | 2011-06-07 | 4 | 0d |  | Contracting Specialist | 40h |  |
| 6 | 1.5 | Request Permits |  | 1d | 2011-06-08 | 2011-06-08 | 5 | 0d |  | Contracting Specialist | 8h |  |
| 7 | 1.6 | Obtain Permits |  | 1w | 2011-06-09 | 2011-06-15 | 6 | 0d |  | Contracting Specialist | 40h | 500 |
| 8 | 1.7 | Obtain Bids |  | 1.38w | 2011-06-17 | 2011-06-27 | 7FS+1d | 0d |  | Contracting Specialist [50%]; Superintendent [50%] | 47.5h |  |
| 9 | 1.8 | Select Subcontractors |  | 1w | 2011-06-27 | 2011-07-04 | 8 | 0d | start no earlier than 2002-07-29 | Superintendent | 40h |  |
| 10 | 1.9 | Complete Planning Phase | milestone | 0d | 2011-07-04 | 2011-07-04 | 9 | 0d |  |  |  |  |
| 11 | 2 | **Structure** |  | 40.5d | 2011-07-04 | 2011-08-30 |  | 0d |  |  | 788h | 29,500 |
| 12 | 2.1 | **Build Structure** |  | 40.5d | 2011-07-04 | 2011-08-30 |  | 0d |  |  | 788h | 29,500 |
| 13 | 2.1.1 | **Build Foundation** |  | 6.5d | 2011-07-04 | 2011-07-13 |  | 0d |  |  | 240h |  |
| 14 | 2.1.1.1 | Dig Foundation |  | 3d | 2011-07-04 | 2011-07-07 | 10 | 0d | start no earlier than 2002-08-09 | Backhoe Operator [200%]; Backhoe [200%] | 96h |  |
| 15 | 2.1.1.2 | Smooth Foundation |  | 2.5d | 2011-07-07 | 2011-07-12 | 14FS-1d | 0d |  | Backhoe Operator [200%]; Backhoe [200%] | 96h |  |
| 16 | 2.1.1.3 | Pour Foundation |  | 1d | 2011-07-12 | 2011-07-13 | 15 | 0d |  | Laborer; Concrete [4000%] | 48h |  |
| 17 | 2.1.2 | **Construct Frame** |  | 10d | 2011-07-15 | 2011-07-29 | 13FS+2d | 0d |  |  | 192h | 26,500 |
| 18 | 2.1.2.1 | Frame House |  | 6d | 2011-07-15 | 2011-07-25 |  | 0d |  | Carpenter [300%] | 144h | 20,000 |
| 19 | 2.1.2.2 | Frame Garage |  | 3d | 2011-07-26 | 2011-07-29 | 18 | 0d |  | Carpenter [200%] | 48h | 6,500 |
| 20 | 2.1.3 | Install Roof |  | 1w | 2011-07-29 | 2011-08-05 | 17 | 0d |  | Roofer [200%]; Roofing Materials | 81h |  |
| 21 | 2.1.4 | Install Doors |  | 3d | 2011-08-05 | 2011-08-10 | 20 | 0d |  | Laborer [200%]; Doors [1000%] | 58h |  |
| 22 | 2.1.5 | Install Windows |  | 4d | 2011-08-12 | 2011-08-18 | 21 | 0d |  | Laborer [200%]; Windows [2400%] | 88h |  |
| 23 | 2.1.6 | Install Siding |  | 1w | 2011-08-18 | 2011-08-25 | 22 | 0d |  | Laborer [200%]; Siding Materials | 81h |  |
| 24 | 2.1.7 | Build Deck |  | 3d | 2011-08-25 | 2011-08-30 | 23 | 0d |  | Carpenter [200%] | 48h | 3,000 |
