# House

Schedule from MS Project, 2011-06-10 to 2011-12-14, costs in $.
Office Training Services, Inc.

## Calendars

- Standard: Mon-Fri 08:00-12:00, 13:00-17:00; Sat-Sun off.

## Resources

| Resource |
| --- |
| Surveyor |
| Architect |
| Contracting Specialist |
| Superintendent |
| Backhoe Operator |
| Backhoe |
| Laborer |
| Concrete |
| Carpenter |
| Roofer |
| Roofing Materials |
| Doors |
| Windows |
| Siding Materials |
| Plumber |
| Electrician |
| Cable Specialist |
| Phone Technician |
| Insulation |
| Drywall |
| Painter |
| Paint |
| Tile |
| Plumbing Supplies |
| Light Fixtures |
| Carpet Layer |
| Carpet |
| Landscaper |
| Landscaping Materials |

## Schedule

| ID | WBS | Task | Type | Duration | Start | Finish | Predecessors | Total slack | Free slack | Constraint | Deadline | Resources | Work | Cost |
| --- | --- | --- | --- | --- | --- | --- | --- | --- | --- | --- | --- | --- | --- | --- |
| 1 | 1 | Conduct Site Survey |  | 1d | 2011-06-10 08:00 | 2011-06-10 17:00 |  | 0d |  |  |  | Surveyor [200%] | 16h |  |
| 2 | 2 | Develop Blueprints |  | 2w | 2011-06-13 08:00 | 2011-06-24 17:00 | 1 | 0d |  |  |  | Architect | 72h |  |
| 3 | 3 | Draft Proposal |  | 3d | 2011-06-27 08:00 | 2011-06-29 17:00 | 2 | 0d |  |  | 2011-06-29 17:00 | Contracting Specialist | 24h |  |
| 4 | 4 | Request Bids |  | 1w | 2011-06-30 08:00 | 2011-07-06 17:00 | 3 | 6d | 0d |  |  | Contracting Specialist | 40h |  |
| 5 | 5 | Request Building Permits |  | 1d | 2011-07-07 08:00 | 2011-07-07 17:00 | 4 | 6d | 0d |  | 2011-07-16 17:00 | Contracting Specialist | 8h |  |
| 6 | 6 | Obtain Building Permits |  | 1w | 2011-07-08 08:00 | 2011-07-14 17:00 | 5 | 97.5d | 0d |  |  | Contracting Specialist | 40h | 500 |
| 7 | 7 | Obtain Bids |  | 1w | 2011-07-18 08:00 | 2011-07-22 17:00 | 6FS+1d | 97.5d | 4d |  |  | Contracting Specialist [50%]; Superintendent [50%] | 40h |  |
| 8 | 8 | Select Subcontractors |  | 1w | 2011-07-29 08:00 | 2011-08-04 17:00 | 7 | 93.5d | 0d | start no earlier than 2011-07-29 08:00 |  | Superintendent | 40h |  |
| 9 | 9 | Complete Planning Phase | milestone | 0d | 2011-08-04 17:00 | 2011-08-04 17:00 | 8 | 93.5d |  |  |  |  |  |  |
| 10 | 10 | **Build Structure** |  | 40.5d | 2011-08-09 08:00 | 2011-10-04 12:00 |  | 0d |  |  |  |  | 788h | 29,500 |
| 11 | 10.1 | **Build Foundation** |  | 6.5d | 2011-08-09 08:00 | 2011-08-17 12:00 |  | 0d |  |  |  |  | 240h |  |
| 12 | 10.1.1 | Dig Foundation |  | 3d | 2011-08-09 08:00 | 2011-08-11 17:00 |  | 0d |  | start no earlier than 2011-08-09 08:00 |  | Backhoe Operator [200%]; Backhoe [200%] | 96h |  |
| 13 | 10.1.2 | Smooth Foundation |  | 2.5d | 2011-08-12 08:00 | 2011-08-16 12:00 | 12FS-1d | 0d |  |  |  | Backhoe Operator [200%]; Backhoe [200%] | 96h |  |
| 14 | 10.1.3 | Pour Foundation |  | 1d | 2011-08-16 13:00 | 2011-08-17 12:00 | 13 | 0d |  |  |  | Laborer; Concrete [4000%] | 48h |  |
| 15 | 10.2 | **Construct Frame** |  | 10d | 2011-08-19 13:00 | 2011-09-02 12:00 | 11FS+2d | 0d |  |  |  |  | 192h | 26,500 |
| 16 | 10.2.1 | Frame House |  | 6d | 2011-08-19 13:00 | 2011-08-29 12:00 |  | 0d |  |  |  | Carpenter [300%] | 144h | 20,000 |
| 17 | 10.2.2 | Frame Garage |  | 3d | 2011-08-30 13:00 | 2011-09-02 12:00 | 16 | 0d |  |  |  | Carpenter [200%] | 48h | 6,500 |
| 18 | 10.3 | Install Roof |  | 1w | 2011-09-02 13:00 | 2011-09-09 12:00 | 15 | 0d |  |  |  | Roofer [200%]; Roofing Materials | 81h |  |
| 19 | 10.4 | Install Doors |  | 3d | 2011-09-09 13:00 | 2011-09-14 12:00 | 18 | 0d |  |  |  | Laborer [200%]; Doors [1000%] | 58h |  |
| 20 | 10.5 | Install Windows |  | 4d | 2011-09-16 13:00 | 2011-09-22 12:00 | 19 | 0d |  |  |  | Laborer [200%]; Windows [2400%] | 88h |  |
| 21 | 10.6 | Install Siding |  | 1w | 2011-09-22 13:00 | 2011-09-29 12:00 | 20 | 0d |  |  |  | Laborer [200%]; Siding Materials | 81h |  |
| 22 | 10.7 | Build Deck |  | 3d | 2011-09-29 13:00 | 2011-10-04 12:00 | 21 | 0d |  |  |  | Carpenter [200%] | 48h | 3,000 |
| 23 | 11 | **Build Infrastructure** |  | 51d | 2011-10-04 13:00 | 2011-12-14 12:00 | 10 | 0d |  |  |  |  | 6550h | 10,250 |
| 24 | 11.1 | Initial Plumbing |  | 7d | 2011-10-04 13:00 | 2011-10-13 12:00 |  | 0d |  |  |  | Plumber [200%] | 112h | 150 |
| 25 | 11.2 | Initial Electricity |  | 2w | 2011-10-13 13:00 | 2011-10-27 12:00 | 24 | 0d |  |  |  | Electrician [300%] | 240h | 200 |
| 26 | 11.3 | Security System |  | 1d | 2011-10-27 13:00 | 2011-10-28 12:00 | 25 | 0d |  |  |  |  |  | 2,000 |
| 27 | 11.4 | Install Cable |  | 1d | 2011-10-28 13:00 | 2011-10-31 12:00 | 26 | 0d |  |  |  | Cable Specialist | 8h |  |
| 28 | 11.5 | Run Phone Lines |  | 1d | 2011-10-31 13:00 | 2011-11-01 12:00 | 27 | 0d |  |  |  | Phone Technician | 8h |  |
| 29 | 11.6 | Insulation |  | 4d | 2011-11-01 13:00 | 2011-11-07 12:00 | 28 | 0d |  |  |  | Laborer [300%]; Insulation [300000%] | 3096h |  |
| 30 | 11.7 | Drywall |  | 4d | 2011-11-07 13:00 | 2011-11-11 12:00 | 29 | 0d |  |  |  | Laborer [200%]; Drywall [17000%] | 234h |  |
| 31 | 11.8 | Painting |  | 3d | 2011-11-11 13:00 | 2011-11-16 12:00 | 30 | 0d |  |  |  | Painter [400%]; Paint [2000%] | 116h |  |
| 32 | 11.9 | Flooring |  | 1w | 2011-11-18 13:00 | 2011-11-25 12:00 | 31FS+2d | 0d |  |  |  | Laborer [200%]; Tile [35000%] | 430h |  |
| 33 | 11.10 | Final Plumbing |  | 3d | 2011-11-25 13:00 | 2011-11-30 12:00 | 32 | 0d |  |  |  | Plumber; Plumbing Supplies | 25h |  |
| 34 | 11.11 | Final Electric |  | 3d | 2011-11-30 13:00 | 2011-12-05 12:00 | 33 | 0d |  |  |  | Electrician [200%]; Light Fixtures | 49h |  |
| 35 | 11.12 | Cabinets |  | 2d | 2011-12-05 13:00 | 2011-12-07 12:00 | 34 | 0d |  |  |  |  |  | 5,400 |
| 36 | 11.13 | Wood Trim |  | 3d | 2011-12-07 13:00 | 2011-12-12 12:00 | 35 | 0d |  |  |  |  |  | 2,500 |
| 37 | 11.14 | Carpeting |  | 2d | 2011-12-12 13:00 | 2011-12-14 12:00 | 36 | 0d |  |  |  | Carpet Layer [200%]; Carpet [220000%] | 2232h |  |
| 38 | 12 | Landscape |  | 1w | 2011-11-21 08:00 | 2011-11-25 17:00 |  | 12.5d |  | start no earlier than 2011-11-20 08:00 |  | Landscaper; Landscaping Materials | 41h |  |
| 39 | 13 | Cement Work |  | 2d | 2011-11-25 08:00 | 2011-11-28 17:00 |  | 11.5d |  | start no earlier than 2011-11-25 08:00 |  | Laborer [300%]; Concrete [1500%] | 63h |  |

| ID | WBS | Task | Duration | Start | Finish | Total slack | Constraint |
| --- | --- | --- | --- | --- | --- | --- | --- |
| 40 | 14 | **Status Meeting** | 125.12d | 2011-06-13 08:00 | 2011-12-05 09:00 | 7.38d |  |
| 41 | 14.1 | Status Meeting 1 | 1h | 2011-06-13 08:00 | 2011-06-13 09:00 | 132.38d | start no earlier than 2011-06-13 08:00 |
| 42 | 14.2 | Status Meeting 2 | 1h | 2011-06-20 08:00 | 2011-06-20 09:00 | 127.38d | start no earlier than 2011-06-20 08:00 |
| 43 | 14.3 | Status Meeting 3 | 1h | 2011-06-27 08:00 | 2011-06-27 09:00 | 122.38d | start no earlier than 2011-06-27 08:00 |
| 44 | 14.4 | Status Meeting 4 | 1h | 2011-07-04 08:00 | 2011-07-04 09:00 | 117.38d | start no earlier than 2011-07-04 08:00 |
| 45 | 14.5 | Status Meeting 5 | 1h | 2011-07-11 08:00 | 2011-07-11 09:00 | 112.38d | start no earlier than 2011-07-11 08:00 |
| 46 | 14.6 | Status Meeting 6 | 1h | 2011-07-18 08:00 | 2011-07-18 09:00 | 107.38d | start no earlier than 2011-07-18 08:00 |
| 47 | 14.7 | Status Meeting 7 | 1h | 2011-07-25 08:00 | 2011-07-25 09:00 | 102.38d | start no earlier than 2011-07-25 08:00 |
| 48 | 14.8 | Status Meeting 8 | 1h | 2011-08-01 08:00 | 2011-08-01 09:00 | 97.38d | start no earlier than 2011-08-01 08:00 |
| 49 | 14.9 | Status Meeting 9 | 1h | 2011-08-08 08:00 | 2011-08-08 09:00 | 92.38d | start no earlier than 2011-08-08 08:00 |
| 50 | 14.10 | Status Meeting 10 | 1h | 2011-08-15 08:00 | 2011-08-15 09:00 | 87.38d | start no earlier than 2011-08-15 08:00 |
| 51 | 14.11 | Status Meeting 11 | 1h | 2011-08-22 08:00 | 2011-08-22 09:00 | 82.38d | start no earlier than 2011-08-22 08:00 |
| 52 | 14.12 | Status Meeting 12 | 1h | 2011-08-29 08:00 | 2011-08-29 09:00 | 77.38d | start no earlier than 2011-08-29 08:00 |
| 53 | 14.13 | Status Meeting 13 | 1h | 2011-09-05 08:00 | 2011-09-05 09:00 | 72.38d | start no earlier than 2011-09-05 08:00 |
| 54 | 14.14 | Status Meeting 14 | 1h | 2011-09-12 08:00 | 2011-09-12 09:00 | 67.38d | start no earlier than 2011-09-12 08:00 |
| 55 | 14.15 | Status Meeting 15 | 1h | 2011-09-19 08:00 | 2011-09-19 09:00 | 62.38d | start no earlier than 2011-09-19 08:00 |
| 56 | 14.16 | Status Meeting 16 | 1h | 2011-09-26 08:00 | 2011-09-26 09:00 | 57.38d | start no earlier than 2011-09-26 08:00 |
| 57 | 14.17 | Status Meeting 17 | 1h | 2011-10-03 08:00 | 2011-10-03 09:00 | 52.38d | start no earlier than 2011-10-03 08:00 |
| 58 | 14.18 | Status Meeting 18 | 1h | 2011-10-10 08:00 | 2011-10-10 09:00 | 47.38d | start no earlier than 2011-10-10 08:00 |
| 59 | 14.19 | Status Meeting 19 | 1h | 2011-10-17 08:00 | 2011-10-17 09:00 | 42.38d | start no earlier than 2011-10-17 08:00 |
| 60 | 14.20 | Status Meeting 20 | 1h | 2011-10-24 08:00 | 2011-10-24 09:00 | 37.38d | start no earlier than 2011-10-24 08:00 |
| 61 | 14.21 | Status Meeting 21 | 1h | 2011-10-31 08:00 | 2011-10-31 09:00 | 32.38d | start no earlier than 2011-10-31 08:00 |
| 62 | 14.22 | Status Meeting 22 | 1h | 2011-11-07 08:00 | 2011-11-07 09:00 | 27.38d | start no earlier than 2011-11-07 08:00 |
| 63 | 14.23 | Status Meeting 23 | 1h | 2011-11-14 08:00 | 2011-11-14 09:00 | 22.38d | start no earlier than 2011-11-14 08:00 |
| 64 | 14.24 | Status Meeting 24 | 1h | 2011-11-21 08:00 | 2011-11-21 09:00 | 17.38d | start no earlier than 2011-11-21 08:00 |
| 65 | 14.25 | Status Meeting 25 | 1h | 2011-11-28 08:00 | 2011-11-28 09:00 | 12.38d | start no earlier than 2011-11-28 08:00 |
| 66 | 14.26 | Status Meeting 26 | 1h | 2011-12-05 08:00 | 2011-12-05 09:00 | 7.38d | start no earlier than 2011-12-05 08:00 |
