# Jones House

Schedule from MS Project, 2011-08-12 to 2011-10-19, costs in $.
Office Training Services, Inc.

## Calendars

- Standard: Mon-Fri 08:00-12:00, 13:00-17:00; Sat-Sun off.

## Schedule

| ID | WBS | Task | Duration | Start | Finish | Predecessors | Total slack | Constraint | Work | Cost |
| --- | --- | --- | --- | --- | --- | --- | --- | --- | --- | --- |
| 1 | 1 | **Establish Residence** | 49d | 2011-08-12 | 2011-10-19 |  | 0d |  | 96h | 29,500 |
| 2 | 1.1 | **Prepare Foundation** | 9d | 2011-08-12 | 2011-08-24 |  | 0d |  | 56h |  |
| 3 | 1.1.1 | Dig Foundation | 4d | 2011-08-12 | 2011-08-17 |  | 0d | start no earlier than 2011-08-12 |  |  |
| 4 | 1.1.2 | Level Foundation | 7d | 2011-08-15 | 2011-08-23 | 3SS | 0d |  | 56h |  |
| 5 | 1.1.3 | Pour Walls | 1d | 2011-08-24 | 2011-08-24 | 4 | 0d |  |  |  |
| 6 | 1.2 | **Construct Frame** | 16d | 2011-08-29 | 2011-09-19 | 2FS+2d | 0d |  |  | 26,500 |
| 7 | 1.2.1 | Frame House | 8d | 2011-08-29 | 2011-09-07 |  | 0d |  |  | 20,000 |
| 8 | 1.2.2 | Frame Garage | 4d | 2011-09-09 | 2011-09-14 | 7 | 0d |  |  | 6,500 |
| 9 | 1.2.3 | Frame Shed | 3d | 2011-09-15 | 2011-09-19 | 8 | 0d |  |  |  |
| 10 | 1.3 | Install Roof | 1w | 2011-09-20 | 2011-09-26 | 6 | 0d | start no earlier than 2002-09-05 |  |  |
| 11 | 1.4 | Install Doors | 5d | 2011-09-27 | 2011-10-03 | 10 | 0d |  |  |  |
| 12 | 1.5 | Install Windows | 5d | 2011-09-27 | 2011-10-03 | 11SS | 0d | start no earlier than 2002-09-23 | 40h |  |
| 13 | 1.6 | Install Siding | 8d | 2011-10-04 | 2011-10-13 | 12 | 0d |  |  |  |
| 14 | 1.7 | Construct Deck | 3d | 2011-10-14 | 2011-10-18 | 13 | 0d |  |  | 3,000 |
| 15 | 1.8 | Install Hot tub | 4d | 2011-10-14 | 2011-10-19 | 14SS | 0d |  |  |  |
