# Planning Phase

Schedule from MS Project, 2011-06-10 to 2011-08-04, costs in $.
Office Training Services, Inc.

## Calendars

- Standard: Mon-Fri 08:00-12:00, 13:00-17:00; Sat-Sun off.

## Resources

| Resource |
| --- |
| Surveyor |
| Architect |
| Contracting Specialist |
| Superintendent |

## Schedule

| ID | WBS | Task | Type | Duration | Start | Finish | Predecessors | Total slack | Free slack | Constraint | Resources | Work | Cost |
| --- | --- | --- | --- | --- | --- | --- | --- | --- | --- | --- | --- | --- | --- |
| 1 | 1 | **Plan** |  | 40d | 2011-06-10 | 2011-08-04 |  | 0d |  |  |  | 287.5h | 500 |
| 2 | 1.1 | Conduct Site Survey |  | 1d | 2011-06-10 | 2011-06-10 |  | 39d |  |  | Surveyor [200%] | 16h |  |
| 3 | 1.2 | Develop Blueprints |  | 2w | 2011-06-10 | 2011-06-23 |  | 3.12d | 0d |  | Architect | 72h |  |
| 4 | 1.3 | Draft Proposal |  | 3d | 2011-06-24 | 2011-06-28 | 3 | 3.12d | 0d |  | Contracting Specialist | 24h |  |
| 5 | 1.4 | Request Bids |  | 1w | 2011-06-29 | 2011-07-05 | 4 | 3.12d | 0d |  | Contracting Specialist | 40h |  |
| 6 | 1.5 | Request Permits |  | 1d | 2011-07-06 | 2011-07-06 | 5 | 3.12d | 0d |  | Contracting Specialist | 8h |  |
| 7 | 1.6 | Obtain Permits |  | 1w | 2011-07-07 | 2011-07-13 | 6 | 3.12d | 0d |  | Contracting Specialist | 40h | 500 |
| 8 | 1.7 | Obtain Bids |  | 1.38w | 2011-07-15 | 2011-07-25 | 7FS+1d | 3.12d |  |  | Contracting Specialist [50%]; Superintendent [50%] | 47.5h |  |
| 9 | 1.8 | Select Subcontractors |  | 1w | 2011-07-29 | 2011-08-04 | 8 | 0d |  | start no earlier than 2011-07-29 | Superintendent | 40h |  |
| 10 | 2 | Complete Planning Phase | milestone | 0d | 2011-08-04 | 2011-08-04 | 9 | 0d |  |  |  |  |  |
