# Template Practice

Schedule from MS Project, 2011-08-22 to 2012-07-05, costs in $, A marks actual dates.
Office Training Services, Inc.

## Calendars

- Standard: Mon-Fri 08:00-12:00, 13:00-17:00; Sat-Sun off.

## Resources

| Resource |
| --- |
| Surveyor |
| Architect |
| Contracting Specialist |
| Superintendent |
| Backhoe Operator |
| Backhoe |
| Laborer |
| Concrete |
| Carpenter |
| Roofer |
| Roofing Materials |
| Doors |
| Windows |
| Siding Materials |
| Plumber |
| Electrician |
| Cable Specialist |
| Phone Technician |
| Insulation |
| Drywall |
| Painter |
| Paint |
| Tile |
| Plumbing Supplies |
| Light Fixtures |
| Carpet Layer |
| Carpet |

## Schedule

| ID | WBS | Task | Type | Duration | Start | Finish | Predecessors | Complete | Total slack | Resources | Work | Actual work | Cost | Actual cost |
| --- | --- | --- | --- | --- | --- | --- | --- | --- | --- | --- | --- | --- | --- | --- |
| 1 | 1 | Conduct Site Survey |  | 1d | 2011-08-22 A | 2011-08-22 A |  | 100% |  | Surveyor [200%] | 16h | 16h |  |  |
| 2 | 2 | Develop Blueprints |  | 2w | 2011-08-23 A | 2011-09-05 A | 1 | 100% |  | Architect | 72h | 72h |  |  |
| 3 | 3 | Draft Proposal |  | 3d | 2011-09-06 A | 2011-09-08 A | 2 | 100% |  | Contracting Specialist | 24h | 24h |  |  |
| 4 | 4 | Request Bids |  | 1w | 2011-09-09 A | 2011-09-15 A | 3 | 100% |  | Contracting Specialist | 40h | 40h |  |  |
| 5 | 5 | Request Permits |  | 1d | 2011-09-16 A | 2011-09-16 A | 4 | 100% |  | Contracting Specialist | 8h | 8h |  |  |
| 6 | 6 | Obtain Permits |  | 1w | 2011-09-19 A | 2011-09-23 A | 5 | 100% |  | Contracting Specialist | 40h | 40h | 500 | 500 |
| 7 | 7 | Get Bids |  | 1.38w | 2011-09-27 A | 2011-10-05 A | 6FS+1d | 100% |  | Contracting Specialist [50%]; Superintendent [50%] | 47.5h | 47.5h |  |  |
| 8 | 8 | Select Subcontractors |  | 1w | 2011-10-05 A | 2011-10-12 A | 7 | 100% |  | Superintendent | 40h | 40h |  |  |
| 9 | 9 | Complete Planning Phase | milestone | 0d | 2011-10-12 A | 2011-10-12 A | 8 | 100% |  |  |  |  |  |  |
| 10 | 10 | **Build Structure** |  | 32d | 2011-08-22 A | 2011-10-04 A |  | 100% |  |  | 788h | 788h | 29,500 | 29,500 |
| 11 | 10.1 | **Build Foundation** |  | 6.5d | 2011-08-22 A | 2011-08-30 A |  | 100% |  |  | 240h | 240h |  |  |
| 12 | 10.1.1 | Dig Foundation |  | 3d | 2011-08-22 A | 2011-08-24 A |  | 100% |  | Backhoe Operator [200%]; Backhoe [200%] | 96h | 96h |  |  |
| 13 | 10.1.2 | Smooth Foundation |  | 2.5d | 2011-08-25 A | 2011-08-29 A | 12FS-1d | 100% |  | Backhoe Operator [200%]; Backhoe [200%] | 96h | 96h |  |  |
| 14 | 10.1.3 | Pour Foundation |  | 1d | 2011-08-29 A | 2011-08-30 A | 13 | 100% |  | Laborer; Concrete [500%] | 48h | 48h |  |  |
| 15 | 10.2 | **Construct Frame** |  | 10d | 2011-08-22 A | 2011-09-02 A | 11FS+2d | 100% |  |  | 192h | 192h | 26,500 | 26,500 |
| 16 | 10.2.1 | Frame House |  | 6d | 2011-08-22 A | 2011-08-29 A |  | 100% |  | Carpenter [300%] | 144h | 144h | 20,000 | 20,000 |
| 17 | 10.2.2 | Frame Garage |  | 3d | 2011-08-31 A | 2011-09-02 A | 16 | 100% |  | Carpenter [200%] | 48h | 48h | 6,500 | 6,500 |
| 18 | 10.3 | Install Roof |  | 1w | 2011-09-05 A | 2011-09-09 A | 15 | 100% |  | Roofer [200%]; Roofing Materials [2.5%] | 81h | 81h |  |  |
| 19 | 10.4 | Install Doors |  | 3d | 2011-09-12 A | 2011-09-14 A | 18 | 100% |  | Laborer [200%]; Doors [41.7%] | 58h | 58h |  |  |
| 20 | 10.5 | Install Windows |  | 4d | 2011-09-19 A | 2011-09-22 A | 19 | 100% |  | Laborer [200%]; Windows [75%] | 88h | 88h |  |  |
| 21 | 10.6 | Install Siding |  | 1w | 2011-09-23 A | 2011-09-29 A | 20 | 100% |  | Laborer [200%]; Siding Materials [2.5%] | 81h | 81h |  |  |
| 22 | 10.7 | Build Deck |  | 3d | 2011-09-30 A | 2011-10-04 A | 21 | 100% |  | Carpenter [200%] | 48h | 48h | 3,000 | 3,000 |
| 23 | 11 | **Build Infrastructure** |  | 196.56d | 2011-10-05 | 2012-07-05 | 10 |  | 0d |  | 4249h |  | 10,250 |  |
| 24 | 11.1 | Initial Plumbing |  | 7d | 2011-10-05 | 2011-10-13 |  |  | 0d | Plumber [200%] | 112h |  | 150 |  |
| 25 | 11.2 | Initial Electricity |  | 2w | 2011-10-05 | 2011-10-18 | 24SS |  | 0d | Electrician [300%] | 240h |  | 200 |  |
| 26 | 11.3 | Security System |  | 1d | 2011-10-19 | 2011-10-19 | 25 |  | 0d |  |  |  | 2,000 |  |
| 27 | 11.4 | Install Cable |  | 1d | 2011-10-19 | 2011-10-19 | 26SS |  | 0d | Cable Specialist | 8h |  |  |  |
| 28 | 11.5 | Run Phone Lines |  | 1d | 2011-10-19 | 2011-10-19 | 27SS |  | 0d | Phone Technician | 8h |  |  |  |
| 29 | 11.6 | Insulation |  | 129d | 2011-10-20 | 2012-04-17 | 28 |  | 0d | Laborer [300%]; Insulation [0.1%] | 3097h |  |  |  |
| 30 | 11.7 | Drywall |  | 14.62d | 2012-04-18 | 2012-05-08 | 29 |  | 0d | Laborer [200%]; Drywall [0.9%] | 235h |  |  |  |
| 31 | 11.8 | Painting |  | 3d | 2012-05-08 | 2012-05-11 | 30 |  | 0d | Painter; Paint [4.2%] | 25h |  |  |  |
| 32 | 11.9 | Flooring |  | 5.38w | 2012-05-15 | 2012-06-21 | 31FS+2d |  | 0d | Laborer [200%]; Tile [0.5%] | 431h |  |  |  |
| 33 | 11.10 | Final Plumbing |  | 3.12d | 2012-06-21 | 2012-06-26 | 32 |  | 0d | Plumber; Plumbing Supplies [4%] | 26h |  |  |  |
| 34 | 11.11 | Final Electric |  | 3.06d | 2012-06-21 | 2012-06-26 | 33SS |  | 0d | Electrician [200%]; Light Fixtures [4.1%] | 50h |  |  |  |
| 35 | 11.12 | Cabinets |  | 2d | 2012-06-26 | 2012-06-28 | 34 |  | 0d |  |  |  | 5,400 |  |
| 36 | 11.13 | Wood Trim |  | 3d | 2012-06-28 | 2012-07-03 | 35 |  | 0d |  |  |  | 2,500 |  |
| 37 | 11.14 | Carpeting |  | 2d | 2012-07-03 | 2012-07-05 | 36 |  | 0d | Carpet Layer; Carpet [6.2%] | 17h |  |  |  |
